# Cooling_plan_23June2004

Schedule from MS Project, 2004-06-23 to 2004-08-13.
CERN

## Calendars

- Standard: Mon-Fri 08:00-12:00, 13:00-17:00; Sat-Sun off.

## Schedule

| ID | Task | Duration | Start | Finish | Predecessors | Total slack | Free slack |
| --- | --- | --- | --- | --- | --- | --- | --- |
| 1 | Check min flow, stability, 2 capillaries only, heater power with 0% power | 5d? | 2004-06-23 | 2004-06-29 |  | 0d |  |
| 2 | finalise capillaries for EC + measure Dp inlet tubes | 8d? | 2004-06-30 | 2004-07-09 | 1 | 0d |  |
| 3 | define final tube sizes PP_1-racks | 2d? | 2004-07-12 | 2004-07-13 | 2 | 18d |  |
| 4 | ask quotation for capillary | 10d? | 2004-07-12 | 2004-07-23 | 2 | 7d | 0d |
| 5 | order capillary for EC | 3d? | 2004-07-26 | 2004-07-28 | 4 | 7d |  |
| 6 | test on-disk loop | 15d? | 2004-07-05 | 2004-07-23 | 2FS-5d | 0d |  |
| 7 | make prototype of barrel HEX | 18d? | 2004-06-23 | 2004-07-16 |  | 15d |  |
| 8 | test stability of big heater | 5d? | 2004-07-26 | 2004-07-30 | 6 | 5d |  |
| 9 | test barrel HEX | 15d? | 2004-07-26 | 2004-08-13 | 6 | 0d |  |
| 10 | test on-barrel loop | 1d? | 2004-06-23 | 2004-06-23 |  | 32d |  |
| 11 | finalize capillaries for barrel SCT | 1d? | 2004-06-23 | 2004-06-23 |  | 32d |  |
| 12 | test pixel capillaries | 1d? | 2004-06-23 | 2004-06-23 |  | 32d |  |
| 13 | measure pressure drops across filters and electrical breaks | 1d? | 2004-06-23 | 2004-06-23 |  | 32d |  |
