# Cooling_plan_3Oct2003

Schedule from MS Project, 2003-07-07 to 2004-03-10.
CERN

## Calendars

- Standard: Mon-Fri 08:00-12:00, 13:00-17:00; Sat-Sun off.

## Resources

| Resource |
| --- |
| Marek |
| Vincent Hedberg |
| Stephane |
| Bogdan |
| student |
| Andy |
| Jaso |
| Neal |
| Jason |
| Pippa |
| Claude |
| Pierre |
| Richard |
| Richard D. |
| Stephen Butterworth |
| Richard B. |
| Vic |
| Marco |
| RAL |

## Schedule

| ID | WBS | Task | Type | Duration | Start | Finish | Predecessors | Total slack | Free slack | Constraint | Resources | Work |
| --- | --- | --- | --- | --- | --- | --- | --- | --- | --- | --- | --- | --- |
| 1 | 1 | **Test at CERN** |  | 155d? | 2003-07-07 | 2004-02-06 |  | 1d |  |  |  | 2496h |
| 2 | 1.1 | **Setup improvement** |  | 30d? | 2003-09-08 | 2003-10-17 |  | 4d |  |  |  | 240h |
| 3 | 1.1.1 | procure liquid flow meter and pressure sensors |  | 30d? | 2003-09-08 | 2003-10-17 |  | 4d |  | start no earlier than 2003-09-08 | Bogdan | 240h |
| 4 | 1.2 | Complete tests on Pixel heat exchanger |  | 12d? | 2003-10-02 | 2003-10-17 |  | 0d |  | start no earlier than 2003-10-02 | Vic; Richard B. | 192h |
| 5 | 1.3 | **Heater** |  | 29d | 2003-09-17 | 2003-10-27 |  | 0d |  |  |  | 264h |
| 6 | 1.3.1 | new heater control |  | 23d | 2003-09-17 | 2003-10-17 |  | 0d |  | start no earlier than 2003-09-17 | Stephane | 184h |
| 7 | 1.3.2 | test final heater prototypes |  | 4d | 2003-10-20 | 2003-10-23 | 4, 6 | 0d |  |  | Bogdan; Stephane | 64h |
| 8 | 1.3.3 | Report on the heater tests for the review |  | 2d | 2003-10-24 | 2003-10-27 | 7 | 80d | 6d |  | Stephane | 16h |
| 9 | 1.4 | PRR of external system | milestone | 0d | 2003-11-05 | 2003-11-05 | 8 | 32d |  | start no earlier than 2003-11-05 |  |  |
| 10 | 1.5 | **Capillary** |  | 89d? | 2003-07-07 | 2003-11-06 |  | 0d |  |  |  | 760h |
| 11 | 1.5.1 | procurement of capillaries (0.6/0.65/0.7 ID) |  | 75d? | 2003-07-07 | 2003-10-17 |  | 11d | 0d | start no earlier than 2003-07-05 | Andy | 600h |
| 12 | 1.5.2 | Measure ID and prepare test samples |  | 3d | 2003-10-20 | 2003-10-22 | 11 | 11d | 1d |  |  |  |
| 13 | 1.5.3 | Capillary tests |  | 10d | 2003-10-24 | 2003-11-06 | 7, 12, 3 | 0d |  | start no earlier than 2003-09-06 | Bogdan; Richard B. | 160h |
| 14 | 1.6 | **study of EC SCT heat exchanger** |  | 30d | 2003-11-07 | 2003-12-18 |  | 0d |  |  |  | 408h |
| 15 | 1.6.1 | New prototype with final capillary |  | 3d | 2003-11-07 | 2003-11-11 | 13 | 0d |  |  | Pierre | 24h |
| 16 | 1.6.2 | test prototype |  | 21d | 2003-11-12 | 2003-12-10 | 15 | 0d |  |  | Bogdan; Richard B. | 336h |
| 17 | 1.6.3 | Final report on heat exchanger and capillary tests |  | 6d | 2003-12-11 | 2003-12-18 | 16 | 42d |  |  | Richard | 48h |
| 18 | 1.7 | **Filter** |  | 94d? | 2003-09-30 | 2004-02-06 |  | 23d |  |  |  | 632h |
| 19 | 1.7.1 | Procure samples for both barrel and EC SCT |  | 19d | 2003-09-30 | 2003-10-24 |  | 70d | 0d | start no earlier than 2003-09-30 | Andy | 152h |
| 20 | 1.7.2 | design fitting with filter |  | 19d? | 2003-09-30 | 2003-10-24 |  | 70d | 0d | start no earlier than 2003-09-30 | Jason; Andy | 304h |
| 21 | 1.7.3 | prototype of fitting with filter |  | 8d? | 2003-10-27 | 2003-11-05 | 20, 19 | 70d | 1d | start no earlier than 2003-08-27 | Jason; Andy | 128h |
| 22 | 1.7.4 | test filter on cooling loop |  | 3d | 2003-11-07 | 2003-11-11 | 13, 21 | 69d |  |  | Bogdan; Richard B. | 48h |
| 23 | 1.7.5 | **Liquid Setup for capillary trimming to right length** |  | 41d | 2003-12-12 | 2004-02-06 |  | 6d |  |  |  |  |
| 24 | 1.7.5.1 | Design |  | 7d | 2003-12-12 | 2003-12-22 |  | 6d | 0d | start no earlier than 2003-12-12 |  |  |
| 25 | 1.7.5.2 | Material procurement |  | 21d | 2003-12-23 | 2004-01-20 | 24 | 6d | 0d |  |  |  |
| 26 | 1.7.5.3 | Assembly |  | 10d | 2004-01-21 | 2004-02-03 | 25 | 6d | 0d |  |  |  |
| 27 | 1.7.5.4 | Testing |  | 3d | 2004-02-04 | 2004-02-06 | 26 | 6d |  |  |  |  |

| ID | WBS | Task | Type | Duration | Start | Finish | Predecessors | Total slack | Free slack | Constraint | Resources | Work |
| --- | --- | --- | --- | --- | --- | --- | --- | --- | --- | --- | --- | --- |
| 28 | 2 | **Design and Manufacturing of SCT EC heat exchanger** |  | 116d? | 2003-10-01 | 2004-03-10 |  | 0d |  |  |  | 296h |
| 29 | 2.1 | Detailed design |  | 27d? | 2003-10-01 | 2003-11-06 |  | 3d | 0d | start no earlier than 2003-10-01 | Stephen Butterworth | 216h |
| 30 | 2.2 | Bidding |  | 21d | 2003-11-07 | 2003-12-05 | 29 | 3d |  |  |  |  |
| 31 | 2.3 | Final design and approval |  | 5d | 2003-12-11 | 2003-12-17 | 30, 16 | 0d |  |  | Jason; Marco | 80h |
| 32 | 2.4 | Place orders for parts | milestone | 0d | 2003-12-17 | 2003-12-17 | 31 | 0d |  |  | RAL |  |
| 33 | 2.5 | Procurement |  | 43d | 2003-12-18 | 2004-02-16 | 32 | 0d |  |  |  |  |
| 34 | 2.6 | Testing of capillaries |  | 3d | 2004-02-17 | 2004-02-19 | 33, 27 | 0d |  |  |  |  |
| 35 | 2.7 | Assembly of heat exchanger for 1st disk |  | 10d | 2004-02-20 | 2004-03-04 | 34 | 0d |  |  |  |  |
| 36 | 2.8 | Final testing |  | 4d | 2004-03-05 | 2004-03-10 | 35 | 0d |  |  |  |  |
| 37 | 3 | HEAT EXCHANGERs READY FOR DISK NO. 1 | milestone | 0d | 2004-03-10 | 2004-03-10 | 36 | 0d |  |  |  |  |
