# Cooling_plan_7Nov2003

Schedule from MS Project, 2003-07-07 to 2004-03-12, A marks actual dates.
CERN

## Calendars

- Standard: Mon-Fri 08:00-12:00, 13:00-17:00; Sat-Sun off.

## Resources

| Resource |
| --- |
| Marek |
| Vincent Hedberg |
| Stephane |
| Bogdan |
| student |
| Andy |
| Jaso |
| Neal |
| Jason |
| Pippa |
| Claude |
| Pierre |
| Richard |
| Richard D. |
| Stephen Butterworth |
| Richard B. |
| Vic |
| Marco |
| RAL |
| Valery |

## Schedule

| ID | WBS | Task | Duration | Start | Finish | Predecessors | Complete | Remaining | Total slack | Free slack | Constraint | Resources | Work | Actual work |
| --- | --- | --- | --- | --- | --- | --- | --- | --- | --- | --- | --- | --- | --- | --- |
| 1 | 1 | **Test at CERN** | 121d? | 2003-07-07 A | 2003-12-22 |  | 77% | 28.31d? | 59d |  |  |  | 2032h | 1435.2h |
| 2 | 1.1 | **Setup improvement** | 48d? | 2003-09-08 A | 2003-11-12 |  | 80% | 9.6d? | 1d |  |  |  | 384h | 307.2h |
| 3 | 1.1.1 | procure liquid flow meter and pressure sensors | 48d? | 2003-09-08 A | 2003-11-12 |  | 80% | 9.6d? | 1d |  | start no earlier than 2003-09-08 | Bogdan | 384h | 307.2h |
| 4 | 1.2 | Complete tests on Pixel heat exchanger | 12d? | 2003-10-02 A | 2003-10-17 A |  | 100% |  |  |  | start no earlier than 2003-10-02 | Vic; Richard B. | 192h | 192h |
| 5 | 1.3 | **Heater** | 42d | 2003-09-17 A | 2003-11-13 |  | 79% | 8.71d | 86d |  |  |  | 472h | 336h |
| 6 | 1.3.1 | new heater control | 23d | 2003-09-17 A | 2003-10-17 A |  | 100% |  |  |  | start no earlier than 2003-09-17 | Stephane | 184h | 184h |
| 7 | 1.3.2 | test final heater prototypes | 16d | 2003-10-19 A | 2003-11-10 | 4, 6 | 53% | 7.5d | 6d | 0d |  | Bogdan; Stephane | 256h | 136h |
| 8 | 1.3.3 | Final report on the heater tests | 2d | 2003-11-12 A | 2003-11-13 | 7 | 50% | 1d | 86d |  |  | Bogdan; Richard B. | 32h | 16h |
| 9 | 1.4 | **Capillary** | 100d? | 2003-07-07 A | 2003-11-21 |  | 88% | 11.67d? | 0d |  |  |  | 696h | 600h |
| 10 | 1.4.1 | procurement of capillaries (0.6/0.65/0.7 ID) | 75d? | 2003-07-07 A | 2003-10-17 A |  | 100% |  |  |  | start no earlier than 2003-07-05 | Andy | 600h | 600h |
| 11 | 1.4.2 | Measure ID and prepare test samples | 9d | 2003-11-03 A | 2003-11-13 |  | 50% | 4.5d | 0d |  | start no earlier than 2003-11-02 |  |  |  |
| 12 | 1.4.3 | Capillary tests | 6d | 2003-11-14 | 2003-11-21 | 7FS-3d, 11, 3 |  |  | 0d |  | start no earlier than 2003-09-06 | Bogdan; Richard B. | 96h |  |
| 13 | 1.5 | **study of EC SCT heat exchanger** | 21d | 2003-11-24 | 2003-12-22 |  |  |  | 0d |  |  |  | 288h |  |
| 14 | 1.5.1 | New prototype with final capillary | 3d | 2003-11-24 | 2003-11-26 | 12, 20 |  |  | 0d |  |  | Pierre; Valery | 48h |  |
| 15 | 1.5.2 | test prototype | 12d | 2003-11-27 | 2003-12-12 | 14 |  |  | 0d |  |  | Bogdan; Richard B. | 192h |  |
| 16 | 1.5.3 | Final report on heat exchanger and capillary tests | 6d | 2003-12-15 | 2003-12-22 | 15 |  |  | 59d |  |  | Richard | 48h |  |
| 17 | 2 | **Filter** | 45d? | 2003-09-30 | 2003-12-01 |  |  |  | 0d |  |  |  | 824h |  |
| 18 | 2.1 | Procure samples for both barrel and EC SCT | 19d | 2003-09-30 | 2003-10-24 |  |  |  | 0d |  | start no earlier than 2003-09-30 | Andy | 152h |  |
| 19 | 2.2 | design fitting with filter | 19d? | 2003-09-30 | 2003-10-24 |  |  |  | 0d |  | start no earlier than 2003-09-30 | Jason; Andy | 304h |  |
| 20 | 2.3 | prototype of fitting with filter | 20d? | 2003-10-27 | 2003-11-21 | 19, 18 |  |  | 0d |  | start no earlier than 2003-08-27 | Jason; Andy | 320h |  |
| 21 | 2.4 | test filter on cooling loop | 3d | 2003-11-27 | 2003-12-01 | 20FS+3d |  |  | 74d |  |  | Bogdan; Richard B. | 48h |  |
| 22 | 3 | **Liquid Setup for capillary trimming to right length** | 41d | 2003-12-12 | 2004-02-06 |  |  |  | 8d |  |  |  |  |  |
| 23 | 3.1 | Design | 7d | 2003-12-12 | 2003-12-22 |  |  |  | 8d | 0d | start no earlier than 2003-12-12 |  |  |  |
| 24 | 3.2 | Material procurement | 21d | 2003-12-23 | 2004-01-20 | 23 |  |  | 8d | 0d |  |  |  |  |
| 25 | 3.3 | Assembly | 10d | 2004-01-21 | 2004-02-03 | 24 |  |  | 8d | 0d |  |  |  |  |
| 26 | 3.4 | Testing | 3d | 2004-02-04 | 2004-02-06 | 25 |  |  | 8d |  |  |  |  |  |

| ID | WBS | Task | Type | Duration | Start | Finish | Predecessors | Complete | Remaining | Total slack | Free slack | Constraint | Resources | Work | Actual work |
| --- | --- | --- | --- | --- | --- | --- | --- | --- | --- | --- | --- | --- | --- | --- | --- |
| 27 | 4 | **Design and Manufacturing of SCT EC heat exchanger** |  | 118d? | 2003-10-01 A | 2004-03-12 |  | 13% | 102.74d? | 0d |  |  |  | 320h | 120h |
| 28 | 4.1 | Detailed design |  | 30d? | 2003-10-01 A | 2003-11-11 |  | 50% | 15d? | 2d | 0d | start no earlier than 2003-10-01 | Stephen Butterworth | 240h | 120h |
| 29 | 4.2 | Bidding |  | 21d | 2003-11-12 | 2003-12-10 | 28 |  |  | 2d |  |  |  |  |  |
| 30 | 4.3 | Final design and approval |  | 5d | 2003-12-15 | 2003-12-19 | 29, 15 |  |  | 0d |  |  | Jason; Marco | 80h |  |
| 31 | 4.4 | Place orders for parts | milestone | 0d | 2003-12-19 | 2003-12-19 | 30 |  |  | 0d |  |  | RAL |  |  |
| 32 | 4.5 | Procurement |  | 43d | 2003-12-22 | 2004-02-18 | 31 |  |  | 0d |  |  |  |  |  |
| 33 | 4.6 | Testing of capillaries |  | 3d | 2004-02-19 | 2004-02-23 | 32, 26 |  |  | 0d |  |  |  |  |  |
| 34 | 4.7 | Assembly of heat exchanger for 1st disk |  | 10d | 2004-02-24 | 2004-03-08 | 33 |  |  | 0d |  |  |  |  |  |
| 35 | 4.8 | Final testing |  | 4d | 2004-03-09 | 2004-03-12 | 34 |  |  | 0d |  |  |  |  |  |
| 36 | 5 | HEAT EXCHANGERs READY FOR DISK NO. 1 | milestone | 0d | 2004-03-12 | 2004-03-12 | 35 |  |  | 0d |  |  |  |  |  |
